# PART2

Schedule from MS Project, 2004-01-03 to 2005-08-29, costs in $.
kw university

## Calendars

- Standard: Mon-Wed 08:00-12:00, 13:00-17:00; Thu-Fri off; Sat-Sun 08:00-12:00, 13:00-17:00.

## Resources

| Resource | Rate |
| --- | --- |
| RDK | 150 |
| CEK | 120 |
| ARB | 100 |
| JTP | 100 |
| DLC | 100 |
| MLM | 120 |
| BRD | 100 |
| HLQ | 100 |

## Schedule

| ID | WBS | Task | Duration | Start | Finish | Predecessors | Total slack | Free slack | Resources | Work | Cost |
| --- | --- | --- | --- | --- | --- | --- | --- | --- | --- | --- | --- |
| 1 | 1 | **Requirements Phase** | 146.5d | 2004-01-03 | 2004-07-25 |  | 0.5d |  |  | 524h | 65,160 |
| 2 | 1.1 | Configuration Management Plan | 2d | 2004-01-03 | 2004-01-04 |  | 71.5d | 0d | RDK | 16h | 2,400 |
| 3 | 1.2 | Key users identified | 1d | 2004-01-05 | 2004-01-05 | 2 | 71.5d |  | RDK | 8h | 1,200 |
| 4 | 1.3 | User interviews | 7d | 2004-04-17 | 2004-04-26 | 3 | 0.5d | 0d | CEK | 56h | 6,720 |
| 5 | 1.4 | Use cases developed | 7d | 2004-04-27 | 2004-05-09 | 4 | 0.5d | 0d | CEK | 56h | 6,720 |
| 6 | 1.5 | User interface prototyped developed & approved | 14d | 2004-05-10 | 2004-06-01 | 5 | 0.5d |  | CEK | 112h | 13,440 |
| 7 | 1.6 | Functional requirements writing | 20d | 2004-06-05 | 2004-07-06 | 6, 5 | 0.5d |  | CEK | 160h | 19,200 |
| 8 | 1.7 | Project master test plan | 5d | 2004-07-10 | 2004-07-17 | 7 | 3.5d |  | RDK | 40h | 6,000 |
| 9 | 1.8 | Data Dictionary | 8d | 2004-07-10 | 2004-07-20 | 7 | 0.5d |  | CEK | 64h | 7,680 |
| 10 | 1.9 | Update Project Plan, refine estimates | 1.5d | 2004-07-24 | 2004-07-25 | 9, 8 | 0.5d | 0d | RDK | 12h | 1,800 |
| 11 | 2 | **Functional Design Phase** | 40.5d | 2004-07-25 | 2004-09-19 |  | 0.5d |  |  | 408h | 53,640 |
| 12 | 2.1 | Logical Model | 4d | 2004-07-25 | 2004-08-01 | 10 | 0.5d | 0d | CEK | 32h | 3,840 |
| 13 | 2.2 | Data Dictionary (revised) | 2d | 2004-08-01 | 2004-08-03 | 9, 12 | 0.5d | 0d | CEK | 16h | 1,920 |
| 14 | 2.3 | Requirements Traceability Matrix | 2d | 2004-08-03 | 2004-08-08 | 7, 13 | 0.5d | 0d | CEK | 16h | 1,920 |
| 15 | 2.4 | Software Architecture | 5d | 2004-08-08 | 2004-08-16 | 14 | 0.5d | 0d | CEK | 40h | 4,800 |
| 16 | 2.5 | Functional Design Document | 18.5d | 2004-08-16 | 2004-09-18 | 15 | 0.5d | 0d | RDK; CEK | 296h | 39,960 |
| 17 | 2.6 | Update project plan, refine estimates | 1d | 2004-09-19 | 2004-09-19 | 16 | 0.5d | 0d | RDK | 8h | 1,200 |
| 18 | 3 | **System Design Phase** | 42d | 2004-09-20 | 2004-11-16 |  | 0.5d |  |  | 288h | 34,320 |
| 19 | 3.1 | Physical Model | 5d | 2004-09-20 | 2004-09-27 | 17 | 0.5d | 0d | CEK | 40h | 4,800 |
| 20 | 3.2 | Integration Test Plan (draft) | 2d | 2004-09-28 | 2004-10-02 | 19 | 0.5d | 0d | MLM | 16h | 1,920 |
| 21 | 3.3 | System Test Plan (draft) | 5d | 2004-10-03 | 2004-10-10 | 20 | 0.5d | 0d | MLM | 40h | 4,800 |
| 22 | 3.4 | Subsystem Specifications | 20d | 2004-10-11 | 2004-11-14 | 21 | 0.5d | 0d | CEK | 160h | 19,200 |
| 23 | 3.5 | Programming Standards | 1d | 2004-11-15 | 2004-11-15 | 22 | 0.5d | 0d | ARB; JTP; DLC | 24h | 2,400 |
| 24 | 3.6 | Update project plan, refine estimates | 1d | 2004-11-16 | 2004-11-16 | 23 | 0.5d |  | RDK | 8h | 1,200 |

| ID | WBS | Task | Type | Duration | Start | Finish | Predecessors | Total slack | Free slack | Resources | Work | Cost |
| --- | --- | --- | --- | --- | --- | --- | --- | --- | --- | --- | --- | --- |
| 25 | 4 | **Programming Phase** |  | 77.5d | 2004-11-20 | 2005-03-07 |  | 0.5d |  |  | 2180h | 222,240 |
| 26 | 4.1 | Acceptance Test Plan (draft) |  | 8d | 2004-11-20 | 2004-11-30 | 24 | 0.5d |  | MLM | 64h | 7,680 |
| 27 | 4.2 | Integration Test Plan (final) |  | 8.5d | 2004-12-04 | 2004-12-18 | 26 | 0.5d | 0d | MLM | 68h | 8,160 |
| 28 | 4.3 | System Test Plan (final) |  | 10d | 2004-12-18 | 2005-01-03 | 27 | 0.5d | 0d | MLM | 80h | 9,600 |
| 29 | 4.4 | **Subsystem X1** |  | 45d | 2005-01-03 | 2005-03-07 |  | 0.5d |  |  | 864h | 86,400 |
| 30 | 4.4.1 | code and document |  | 14.5d | 2005-01-03 | 2005-01-29 | 28 | 0.5d | 0d | ARB; JTP; DLC | 348h | 34,800 |
| 31 | 4.4.2 | test and debug |  | 21.5d | 2005-01-30 | 2005-03-07 | 30 | 0.5d | 0d | ARB; JTP; DLC | 516h | 51,600 |
| 32 | 4.5 | **Subsystem X2** |  | 26d | 2005-01-03 | 2005-02-08 |  | 19.5d |  |  | 504h | 50,400 |
| 33 | 4.5.1 | code and document |  | 8.5d | 2005-01-03 | 2005-01-17 | 28 | 19.5d | 0d | ARB; JTP; DLC | 204h | 20,400 |
| 34 | 4.5.2 | test and debug |  | 12.5d | 2005-01-18 | 2005-02-08 | 33 | 19.5d | 19d | ARB; JTP; DLC | 300h | 30,000 |
| 35 | 4.6 | **Subsystem X3** |  | 31d | 2005-01-03 | 2005-02-15 |  | 14.5d |  |  | 600h | 60,000 |
| 36 | 4.6.1 | code and document |  | 10d | 2005-01-03 | 2005-01-22 | 28 | 13.5d | 0d | ARB; JTP; DLC | 240h | 24,000 |
| 37 | 4.6.2 | test and debug |  | 15d | 2005-01-22 | 2005-02-15 | 36 | 14.5d | 14d | ARB; JTP; DLC | 360h | 36,000 |
| 38 | 5 | **System Integration and Testing Phase** |  | 110d | 2005-03-07 | 2005-08-08 |  | 0.5d |  |  | 704h | 70,400 |
| 39 | 5.1 | System integration and integration testing |  | 18d | 2005-03-07 | 2005-04-18 | 31, 34, 37 | 0.5d | 0d | BRD; HLQ | 192h | 19,200 |
| 40 | 5.2 | System test execution and reporting |  | 45d | 2005-04-18 | 2005-08-01 | 39 | 0.5d | 0d | BRD; HLQ | 480h | 48,000 |
| 41 | 5.3 | Acceptance Test Plan (final) |  | 3d | 2005-08-01 | 2005-08-08 | 40 | 0.5d | 0d | BRD; HLQ | 32h | 3,200 |
| 42 | 6 | **Installation and Acceptance Phase** |  | 15d | 2005-08-08 | 2005-08-29 |  | 0d |  |  | 96h | 9,920 |
| 43 | 6.1 | System Installation |  | 2d | 2005-08-08 | 2005-08-13 | 41 | 0.5d | 0d | MLM | 16h | 1,920 |
| 44 | 6.2 | Acceptance Test |  | 7.5d | 2005-08-13 | 2005-08-29 | 43 | 0d |  | BRD; HLQ | 80h | 8,000 |
| 45 | 6.3 | Operational System | milestone | 0d | 2005-08-29 | 2005-08-29 | 44 | 0d |  | BRD; HLQ |  |  |
