# PART1

Schedule from MS Project, 2004-01-03 to 2004-12-04, costs in $.
kw university

## Calendars

- Standard: Mon-Wed 08:00-12:00, 13:00-17:00; Thu-Fri off; Sat-Sun 08:00-12:00, 13:00-17:00.

## Resources

| Resource | Rate |
| --- | --- |
| RDK | 150 |
| CEK | 120 |
| ARB | 100 |
| JTP | 100 |
| DLC | 100 |
| MLM | 120 |
| BRD | 100 |
| HLQ | 100 |

## Schedule

| ID | WBS | Task | Duration | Start | Finish | Predecessors | Total slack | Resources | Work | Cost |
| --- | --- | --- | --- | --- | --- | --- | --- | --- | --- | --- |
| 1 | 1 | **Requirements Phase** | 60.5d | 2004-01-03 | 2004-03-27 |  | 0d |  | 524h | 65,160 |
| 2 | 1.1 | Configuration Management Plan | 2d | 2004-01-03 | 2004-01-04 |  | 0d | RDK | 16h | 2,400 |
| 3 | 1.2 | Key users identified | 1d | 2004-01-05 | 2004-01-05 | 2 | 0d | RDK | 8h | 1,200 |
| 4 | 1.3 | User interviews | 7d | 2004-01-06 | 2004-01-14 | 3 | 0d | CEK | 56h | 6,720 |
| 5 | 1.4 | Use cases developed | 7d | 2004-01-17 | 2004-01-25 | 4 | 0d | CEK | 56h | 6,720 |
| 6 | 1.5 | User interface prototyped developed & approved | 14d | 2004-01-26 | 2004-02-14 | 5 | 0d | CEK | 112h | 13,440 |
| 7 | 1.6 | Functional requirements writing | 20d | 2004-02-15 | 2004-03-13 | 6, 5 | 0d | CEK | 160h | 19,200 |
| 8 | 1.7 | Project master test plan | 5d | 2004-03-14 | 2004-03-20 | 7 | 3d | RDK | 40h | 6,000 |
| 9 | 1.8 | Data Dictionary | 8d | 2004-03-14 | 2004-03-23 | 7 | 0d | CEK | 64h | 7,680 |
| 10 | 1.9 | Update Project Plan, refine estimates | 1.5d | 2004-03-24 | 2004-03-27 | 9, 8 | 0d | RDK | 12h | 1,800 |
| 11 | 2 | **Functional Design Phase** | 32.5d | 2004-03-27 | 2004-05-10 |  | 0d |  | 408h | 53,640 |
| 12 | 2.1 | Logical Model | 4d | 2004-03-27 | 2004-03-31 | 10 | 0d | CEK | 32h | 3,840 |
| 13 | 2.2 | Data Dictionary (revised) | 2d | 2004-03-31 | 2004-04-04 | 9, 12 | 0d | CEK | 16h | 1,920 |
| 14 | 2.3 | Requirements Traceability Matrix | 2d | 2004-04-04 | 2004-04-06 | 7, 13 | 0d | CEK | 16h | 1,920 |
| 15 | 2.4 | Software Architecture | 5d | 2004-04-06 | 2004-04-13 | 14 | 0d | CEK | 40h | 4,800 |
| 16 | 2.5 | Functional Design Document | 18.5d | 2004-04-13 | 2004-05-09 | 15 | 0d | RDK; CEK | 296h | 39,960 |
| 17 | 2.6 | Update project plan, refine estimates | 1d | 2004-05-10 | 2004-05-10 | 16 | 0d | RDK | 8h | 1,200 |
| 18 | 3 | **System Design Phase** | 34d | 2004-05-11 | 2004-06-27 |  | 0d |  | 288h | 34,320 |
| 19 | 3.1 | Physical Model | 5d | 2004-05-11 | 2004-05-17 | 17 | 0d | CEK | 40h | 4,800 |
| 20 | 3.2 | Integration Test Plan (draft) | 2d | 2004-05-18 | 2004-05-19 | 19 | 0d | MLM | 16h | 1,920 |
| 21 | 3.3 | System Test Plan (draft) | 5d | 2004-05-22 | 2004-05-26 | 20 | 0d | MLM | 40h | 4,800 |
| 22 | 3.4 | Subsystem Specifications | 20d | 2004-05-29 | 2004-06-23 | 21 | 0d | CEK | 160h | 19,200 |
| 23 | 3.5 | Programming Standards | 1d | 2004-06-26 | 2004-06-26 | 22 | 0d | ARB; JTP; DLC | 24h | 2,400 |
| 24 | 3.6 | Update project plan, refine estimates | 1d | 2004-06-27 | 2004-06-27 | 23 | 0d | RDK | 8h | 1,200 |

| ID | WBS | Task | Type | Duration | Start | Finish | Predecessors | Total slack | Free slack | Resources | Work | Cost |
| --- | --- | --- | --- | --- | --- | --- | --- | --- | --- | --- | --- | --- |
| 25 | 4 | **Programming Phase** |  | 62.5d | 2004-06-28 | 2004-09-22 |  | 0d |  |  | 2180h | 222,240 |
| 26 | 4.1 | Acceptance Test Plan (draft) |  | 8d | 2004-06-28 | 2004-07-07 | 24 | 0d |  | MLM | 64h | 7,680 |
| 27 | 4.2 | Integration Test Plan (final) |  | 8.5d | 2004-07-10 | 2004-07-20 | 26 | 0d |  | MLM | 68h | 8,160 |
| 28 | 4.3 | System Test Plan (final) |  | 10d | 2004-07-20 | 2004-08-03 | 27 | 0d |  | MLM | 80h | 9,600 |
| 29 | 4.4 | **Subsystem X1** |  | 36d | 2004-08-03 | 2004-09-22 |  | 0d |  |  | 864h | 86,400 |
| 30 | 4.4.1 | code and document |  | 14.5d | 2004-08-03 | 2004-08-23 | 28 | 0d |  | ARB; JTP; DLC | 348h | 34,800 |
| 31 | 4.4.2 | test and debug |  | 21.5d | 2004-08-24 | 2004-09-22 | 30 | 0d |  | ARB; JTP; DLC | 516h | 51,600 |
| 32 | 4.5 | **Subsystem X2** |  | 21d | 2004-08-03 | 2004-09-01 |  | 15d |  |  | 504h | 50,400 |
| 33 | 4.5.1 | code and document |  | 8.5d | 2004-08-03 | 2004-08-15 | 28 | 15d | 0d | ARB; JTP; DLC | 204h | 20,400 |
| 34 | 4.5.2 | test and debug |  | 12.5d | 2004-08-16 | 2004-09-01 | 33 | 15d |  | ARB; JTP; DLC | 300h | 30,000 |
| 35 | 4.6 | **Subsystem X3** |  | 25d | 2004-08-03 | 2004-09-07 |  | 11d |  |  | 600h | 60,000 |
| 36 | 4.6.1 | code and document |  | 10d | 2004-08-03 | 2004-08-17 | 28 | 11d | 0d | ARB; JTP; DLC | 240h | 24,000 |
| 37 | 4.6.2 | test and debug |  | 15d | 2004-08-17 | 2004-09-07 | 36 | 11d |  | ARB; JTP; DLC | 360h | 36,000 |
| 38 | 5 | **System Integration and Testing Phase** |  | 44d | 2004-09-22 | 2004-11-23 |  | 0d |  |  | 704h | 70,400 |
| 39 | 5.1 | System integration and integration testing |  | 12d | 2004-09-22 | 2004-10-10 | 31, 34, 37 | 0d |  | BRD; HLQ | 192h | 19,200 |
| 40 | 5.2 | System test execution and reporting |  | 30d | 2004-10-10 | 2004-11-21 | 39 | 0d |  | BRD; HLQ | 480h | 48,000 |
| 41 | 5.3 | Acceptance Test Plan (final) |  | 2d | 2004-11-21 | 2004-11-23 | 40 | 0d |  | BRD; HLQ | 32h | 3,200 |
| 42 | 6 | **Installation and Acceptance Phase** |  | 7d | 2004-11-23 | 2004-12-04 |  | 0d |  |  | 96h | 9,920 |
| 43 | 6.1 | System Installation |  | 2d | 2004-11-23 | 2004-11-27 | 41 | 0d |  | MLM | 16h | 1,920 |
| 44 | 6.2 | Acceptance Test |  | 5d | 2004-11-27 | 2004-12-04 | 43 | 0d |  | BRD; HLQ | 80h | 8,000 |
| 45 | 6.3 | Operational System | milestone | 0d | 2004-12-04 | 2004-12-04 | 44 | 0d |  | BRD; HLQ |  |  |
